# Cas TNP

Schedule from MS Project, 2014-05-19 to 2015-03-27, costs in €.

## Calendars

- Standard: Mon-Fri 08:00-12:00, 13:00-17:00; Sat-Sun off.

## Resources

| Resource | Group | Rate | Cost per use |
| --- | --- | --- | --- |
| ING DI | TERTEL | 150 |  |
| TEC DI | TERTEL | 80 |  |
| Sous-traitant n°1 | PRINT SYSTEM |  | 1500 |
| Sous-traitant n°2 | PRINT SYSTEM |  | 50000 |
| Sous-traitant n°3 | PRINT SYSTEM |  | 30000 |
| Sous-traitant n°4 | PRINT SYSTEM |  | 40000 |
| TEC DE | TERTEL | 60 |  |
| ING DE | TERTEL | 90 |  |

## Schedule

| ID | WBS | Task | Type | Duration | Start | Finish | Predecessors | Total slack | Free slack | Resources | Work | Cost |
| --- | --- | --- | --- | --- | --- | --- | --- | --- | --- | --- | --- | --- |
| 1 | 1 | **Projet TNP** |  | 225d | 2014-05-19 | 2015-03-27 |  | 0d |  |  | 6230h | 643,900 |
| 2 | Jalon 1 | Début du projet | milestone | 0d | 2014-05-19 | 2014-05-19 |  | 0d |  |  |  |  |
| 3 | 1.1 | Combiné |  | 30d | 2015-01-12 | 2015-02-20 | 6 | 0d |  | Sous-traitant n°2 | 240h | 50,000 |
| 4 | Jalon 7 | Fin du Combiné | milestone | 0d | 2015-02-20 | 2015-02-20 | 3 | 0d |  |  |  |  |
| 5 | 1.2 | Alimentation |  | 20d | 2014-12-15 | 2015-01-09 | 12, 16 | 0d |  | Sous-traitant n°3 | 160h | 30,000 |
| 6 | Jalon 6 | Fin d'Alimentation | milestone | 0d | 2015-01-09 | 2015-01-09 | 5 | 0d |  |  |  |  |
| 7 | 1.3 | **Electronique** |  | 130d | 2014-06-16 | 2014-12-12 |  | 0d |  |  | 2470h | 211,000 |
| 8 | 1.3.1 | Analyseur Synthétiseur |  | 50d | 2014-06-16 | 2014-08-22 | 36 | 0d |  | ING DE [125%]; TEC DE [75%] | 800h | 63,000 |
| 9 | Jalon 3 | Fin de l'analyseur synthétiseur | milestone | 0d | 2014-08-22 | 2014-08-22 | 8 | 0d |  |  |  |  |
| 10 | 1.3.2 | Antenne |  | 30d | 2014-10-20 | 2014-11-28 | 14 | 60d |  | ING DE [83.3%]; TEC DE [41.7%] | 300h | 24,000 |
| 11 | 1.3.3 | Amplificateur de puissance |  | 40d | 2014-10-20 | 2014-12-12 | 14 | 0d |  | Sous-traitant n°4 | 320h | 40,000 |
| 12 | Jalon 5 | Fin d'Amplificateur de puissance | milestone | 0d | 2014-12-12 | 2014-12-12 | 11 | 0d |  |  |  |  |
| 13 | 1.3.4 | Emetteur - Recepteur |  | 40d | 2014-08-25 | 2014-10-17 | 9 | 0d |  | ING DE [93.8%]; TEC DE [46.9%] | 450h | 36,000 |
| 14 | Jalon 4 | Fin Emetteur - Recepteur | milestone | 0d | 2014-10-17 | 2014-10-17 | 13 | 0d |  |  |  |  |
| 15 | 1.3.5 | Codeur - Décodeur |  | 30d | 2014-06-16 | 2014-07-25 | 36 | 70d | 0d | ING DE [83.3%]; TEC DE [41.7%] | 300h | 24,000 |
| 16 | 1.3.6 | Modulateur - Démodulateur |  | 30d | 2014-07-28 | 2014-09-05 | 15 | 70d |  | ING DE [83.3%]; TEC DE [41.7%] | 300h | 24,000 |
| 17 | 1.4 | **Logiciel LOGIC** |  | 95d | 2014-06-16 | 2014-10-24 |  | 85d |  |  | 2460h | 259,900 |
| 18 | 1.4.A | Réaliser les spécifications et la conception générale du logiciel |  | 30d | 2014-06-16 | 2014-07-25 | 36 | 85d | 0d | ING DI [200%]; TEC DI | 720h | 91,200 |
| 19 | 1.4.B | Tester le fonctionnement de l'ensemble des modules |  | 20d | 2014-09-29 | 2014-10-24 | 26, 30 | 85d | 0d | ING DI [50%]; TEC DI | 240h | 24,800 |
| 20 | 1.4.1 | **Module N°1** |  | 15d | 2014-07-28 | 2014-08-15 |  | 85d |  |  | 120h | 18,000 |
| 21 | 1.4.1.A | Coder, tester et intégrer le Module 1 |  | 15d | 2014-07-28 | 2014-08-15 | 18 | 85d | 0d | ING DI | 120h | 18,000 |
| 22 | Jalon 2 | Fin du Module N°1 | milestone | 0d | 2014-08-15 | 2014-08-15 | 21 | 85d | 0d |  |  |  |
| 23 | 1.4.2 | **Module N°2** |  | 10d | 2014-07-28 | 2014-08-08 |  | 105d |  |  | 40h | 6,000 |
| 24 | 1.4.2.A | Coder, tester et intégrer le Module 2 |  | 10d | 2014-07-28 | 2014-08-08 | 18 | 105d | 0d | ING DI [50%] | 40h | 6,000 |

| ID | WBS | Task | Type | Duration | Start | Finish | Predecessors | Total slack | Free slack | Resources | Work | Cost |
| --- | --- | --- | --- | --- | --- | --- | --- | --- | --- | --- | --- | --- |
| 25 | 1.4.3 | **Module N°3** |  | 15d | 2014-08-11 | 2014-08-29 |  | 105d |  |  | 300h | 32,400 |
| 26 | 1.4.3.A | Coder, tester et intégrer le Module 3 |  | 15d | 2014-08-11 | 2014-08-29 | 24 | 105d | 20d | ING DI; TEC DI [150%] | 300h | 32,400 |
| 27 | 1.4.4 | **Module N°4** |  | 10d | 2014-08-18 | 2014-08-29 |  | 85d |  |  | 160h | 18,400 |
| 28 | 1.4.4.A | Coder, tester et intégrer le Module 4 |  | 10d | 2014-08-18 | 2014-08-29 | 22 | 85d | 0d | ING DI; TEC DI | 160h | 18,400 |
| 29 | 1.4.5 | **Module N°5** |  | 20d | 2014-09-01 | 2014-09-26 |  | 85d |  |  | 320h | 25,600 |
| 30 | 1.4.5.A | Coder, tester et intégrer le Module 5 |  | 20d | 2014-09-01 | 2014-09-26 | 28 | 85d | 0d | TEC DI [200%] | 320h | 25,600 |
| 31 | 1.4.6 | **Doc technique et mode d'emploi** |  | 35d | 2014-08-18 | 2014-10-03 |  | 100d |  |  | 560h | 43,500 |
| 32 | 1.4.6.A | Rédiger la documentation technique et le mode d'emploi et les faire imprimer |  | 35d | 2014-08-18 | 2014-10-03 | 22 | 100d | 15d | ING DI; Sous-traitant n°1 | 560h | 43,500 |
| 33 | Jalon 8 | Fin du logiciel LOGIC | milestone | 0d | 2014-10-24 | 2014-10-24 | 32, 19 | 85d |  |  |  |  |
| 34 | 1.5 | **Dossiers** |  | 225d | 2014-05-19 | 2015-03-27 |  | 0d |  |  | 900h | 93,000 |
| 35 | 1.5.1 | Dossier des spécifications |  | 20d | 2014-05-19 | 2014-06-13 | 2 | 0d |  | ING DI [62.5%]; TEC DI [31.2%]; ING DE [62.5%]; TEC DE [31.2%] | 300h | 31,000 |
| 36 | Jalon 2 | Fin du dossier de spécifications du TNP | milestone | 0d | 2014-06-13 | 2014-06-13 | 35 | 0d |  |  |  |  |
| 37 | 1.5.2 | Rapport sur les tests d'ensemble |  | 25d | 2015-02-23 | 2015-03-27 | 4, 10, 33 | 0d |  | ING DI; TEC DI [50%]; ING DE; TEC DE [50%] | 600h | 62,000 |
| 38 | Jalon 3 | Fin du projet | milestone | 0d | 2015-03-27 | 2015-03-27 | 37 | 0d |  |  |  |  |
